# CPF2015

Schedule from MS Project, 2015-01-05 to 2015-07-29.

## Calendars

- Standard: Mon-Fri 08:00-12:00, 13:00-17:00; Sat-Sun off.

## Resources

| Resource |
| --- |
| SE |
| EE |
| ME |
| EM Tech |
| EE Tech |
| Mechanical Tech |
| Machine Shop |

## Schedule

| ID | WBS | Task | Duration | Start | Finish | Predecessors | Total slack | Free slack | Constraint | Resources | Work |
| --- | --- | --- | --- | --- | --- | --- | --- | --- | --- | --- | --- |
| 1 | 1 | CPF-2G Tank Testing | 5d? | 2015-03-03 | 2015-03-10 | 4, 5, 6, 7, 8, 10, 21 | 48.33d | 0d |  | ME | 40h |
| 3 | 2 | **Software** | 148d? | 2015-01-05 | 2015-07-29 |  | 0d |  |  |  | 568h |
| 4 | 2.1 | **Improve error handling** | 16.67d? | 2015-01-05 | 2015-01-27 |  | 55d | 0d |  |  | 80h |
| 5 | 2.1.1 | Harmonize try/catch/finally | 8.33d? | 2015-01-05 | 2015-01-15 |  | 55d | 0d |  | SE [60%] | 40h |
| 6 | 2.1.2 | Execution constraints | 8.33d? | 2015-01-15 | 2015-01-27 | 5 | 55d | 25d |  | SE [60%] | 40h |
| 7 | 2.2 | Harmonize queue call | 3.33d? | 2015-01-27 | 2015-01-30 | 4 | 55d | 0d |  | SE [60%] | 16h |
| 8 | 2.3 | Harmonize log file formatting | 3.33d? | 2015-02-02 | 2015-02-05 | 7 | 55d | 0d |  | SE [60%] | 16h |
| 9 | 2.4 | Harmonize serial port event handlers | 3.33d? | 2015-02-05 | 2015-02-10 | 8 | 55d | 0d |  | SE [60%] | 16h |
| 10 | 2.5 | Clean up hierarchical states | 8.33d? | 2015-02-10 | 2015-02-20 | 9 | 55d | 0d |  | SE [60%] | 40h |
| 11 | 2.6 | Integrate SPI UARTs | 8.33d? | 2015-02-23 | 2015-03-05 | 10 | 79.67d | 0d |  | SE [60%] | 40h |
| 12 | 2.7 | **"Instrument" the software** | 41.67d? | 2015-03-05 | 2015-05-01 | 11 | 63d |  |  |  | 200h |
| 13 | 2.7.1 | GC probes | 8.33d? | 2015-04-09 | 2015-04-21 |  | 71.33d |  |  | SE [60%] | 40h |
| 14 | 2.7.2 | Performance profiler | 8.33d? | 2015-04-21 | 2015-05-01 |  | 63d |  |  | SE [60%] | 40h |
| 15 | 2.7.3 | Performance testing and mitigation | 25d? | 2015-03-05 | 2015-04-09 |  | 79.67d |  |  | SE [60%] | 120h |
| 16 | 2.8 | Work on energy saving | 16.67d? | 2015-05-04 | 2015-05-26 |  | 46.33d |  |  | SE [60%] | 80h |
| 17 | 2.9 | Fix issues that pop up | 16.67d? | 2015-05-26 | 2015-06-18 |  | 29.67d |  |  | SE [60%] | 80h |
| 18 | 2.10 | Improve Google Earth nav app | 1d? | 2015-07-29 | 2015-07-29 |  | 0d |  | start no earlier than 2015-07-29 |  |  |
| 20 | 3 | **Electrical** | 99.67d? | 2015-01-05 | 2015-05-22 |  | 48.33d |  |  |  | 360h |
| 21 | 3.1 | Finish the Power Dist board | 41.67d? | 2015-01-05 | 2015-03-03 |  | 48.33d | 0d |  | EE [60%] | 200h |
| 22 | 3.2 | 2nd spin of the controller board | 20d? | 2015-04-24 | 2015-05-22 | 36 | 48.33d |  |  | EE | 160h |
| 24 | 4 | **Mechanical** | 2d? | 2015-01-05 | 2015-01-06 |  | 146d |  |  |  | 16h |
| 25 | 4.1 | Improve buoyancy engine effeciency | 1d? | 2015-01-05 | 2015-01-05 |  | 147d |  |  | ME | 8h |
| 26 | 4.2 | Misc | 1d? | 2015-01-06 | 2015-01-06 |  | 146d |  |  | ME | 8h |
| 28 | 5 | **System Engineering** | 3d? | 2015-01-07 | 2015-01-09 |  | 143d |  |  |  | 24h |
| 29 | 5.1 | Integrate pH | 1d? | 2015-01-07 | 2015-01-07 |  | 145d |  |  | ME | 8h |
| 30 | 5.2 | Integrate Nitrate | 1d? | 2015-01-08 | 2015-01-08 |  | 144d |  |  | ME | 8h |
| 31 | 5.3 | Integrate Accelerometer | 1d? | 2015-01-09 | 2015-01-09 |  | 143d |  |  | ME | 8h |

| ID | WBS | Task | Duration | Start | Finish | Predecessors | Total slack | Free slack | Constraint |
| --- | --- | --- | --- | --- | --- | --- | --- | --- | --- |
| 33 | 6 | **At sea testing** | 75.33d? | 2015-03-10 | 2015-06-23 |  | 26d |  |  |
| 34 | 6.1 | 1 day test | 1d? | 2015-03-10 | 2015-03-11 | 1 | 48.33d | 0d |  |
| 35 | 6.2 | 1 day test | 1d? | 2015-04-01 | 2015-04-02 | 34FS+15d | 48.33d | 0d |  |
| 36 | 6.3 | 5 day test | 1d? | 2015-04-23 | 2015-04-24 | 35FS+15d | 48.33d | 0d |  |
| 37 | 6.4 | 5 day test | 1d? | 2015-04-23 | 2015-04-24 | 35FS+15d | 68.33d |  |  |
| 38 | 6.5 | Carson contingency day | 1d | 2015-06-23 | 2015-06-23 |  | 26d |  | start no earlier than 2015-06-23 |
